# modular PLASC

Schedule from MS Project, 2014-02-03 to 2015-05-01.
National Assembly for Wales

## Calendars

- Standard: Mon-Fri 08:00-12:00, 13:00-17:00; Sat-Sun off.

## Resources

| Resource |
| --- |
| AM |
| LL |
| MM |
| MP |
| JH |
| LO |
| CP |
| MS |
| SF |
| TG |
| GH |
| gWG |
| WG |
| Suppliers |
| M4/WG |
| Supplers |
| Suppliers/WG |

## Schedule

| ID | WBS | Task | Type | Duration | Start | Finish | Predecessors | Total slack | Free slack | Constraint | Deadline | Resources | Work |
| --- | --- | --- | --- | --- | --- | --- | --- | --- | --- | --- | --- | --- | --- |
| 2 | 1 | NDC 2014 Reporting Arrangements Released |  | 1d | 2014-04-08 | 2014-04-08 |  | 278d |  | start no earlier than 2014-04-08 |  | WG | 8h |
| 4 | 2 | Attendance Secondary 2014 Guidance Notes Released |  | 1d | 2014-04-24 | 2014-04-24 |  | 266d |  | start no earlier than 2014-04-24 |  | WG | 8h |
| 7 | 3 | **WED 2014 on DEWi** |  | 24d | 2014-04-15 | 2014-05-16 |  | 250d |  |  |  | M4/WG | 368h |
| 8 | 3.1 | WED 2014 DEWi development |  | 10d | 2014-04-15 | 2014-04-28 |  | 252d | 0d | start no earlier than 2014-04-15 |  | M4/WG | 80h |
| 9 | 3.2 | WED 2014 DEWi UAT |  | 5d | 2014-04-29 | 2014-05-05 | 8 | 252d | 1d | start no earlier than 2014-04-29 |  | M4/WG | 40h |
| 10 | 3.3 | WED 2014 DEWi rework |  | 3d | 2014-05-07 | 2014-05-09 | 9 | 251d | 0d | start no earlier than 2014-05-07 |  | M4/WG | 24h |
| 11 | 3.4 | WED 2014 Release to test DEWi site | milestone | 1d | 2014-05-12 | 2014-05-12 | 10 | 251d | 1d | start no earlier than 2014-05-12 |  | M4/WG | 8h |
| 12 | 3.5 | WED 2014 DEWi UAT on test site |  | 2d | 2014-05-14 | 2014-05-15 | 11 | 250d | 0d | start no earlier than 2014-05-14 |  | M4/WG | 16h |
| 13 | 3.6 | WED 2014 Release to live DEWi site | milestone | 1d | 2014-05-16 | 2014-05-16 | 12 | 250d |  | start no earlier than 2014-05-16 |  | M4/WG | 8h |
| 15 | 4 | Review and update the ULN collection, also taking account of CTF changes |  | 1d? | 2014-04-15 | 2014-04-15 |  | 273d |  | start no earlier than 2014-04-15 |  | WG | 8h |
| 18 | 5 | CTF14 draft release to suppliers |  | 1d | 2014-02-03 | 2014-02-03 |  | 324d |  | start no earlier than 2014-02-03 |  | WG | 8h |
| 20 | 6 | A_COMP 2014 Review |  | 44d | 2014-02-03 | 2014-04-03 |  | 281d |  | finish no earlier than 2014-04-03 |  | WG | 352h |
| 21 | 7 | CTF14 final release to suppliers |  | 1d | 2014-03-03 | 2014-03-03 |  | 304d |  | start no earlier than 2014-03-03 |  | WG | 8h |
| 23 | 8 | **Spring SDF meetings** |  | 26d | 2014-02-11 | 2014-03-18 |  | -518d | 0d |  |  | Suppliers | 352h |
| 24 | 8.1 | Software Development Forum meeting | milestone | 1d | 2014-02-11 | 2014-02-11 |  | -518d | 0d | start no earlier than 2014-02-11 | 2012-02-16 | Suppliers/WG | 8h |
| 25 | 8.2 | Spec review period: PLASC, EOTAS & Attendance 2015 |  | 16d | 2014-02-13 | 2014-03-06 | 24 | 300d | 7d | start no earlier than 2014-02-13 |  | Suppliers | 128h |
| 26 | 8.3 | Software Development Forum meeting | milestone | 1d | 2014-03-18 | 2014-03-18 | 25 | 293d |  | start no earlier than 2014-03-18 |  | Suppliers/WG | 8h |
| 29 | 9 | **CBDS (standard) change cycle** |  | 1d | 2014-04-02 | 2014-04-02 |  | 282d |  |  |  | WG | 40h |
| 30 | 9.1 | CBDS 1415 published - Pupil/School | milestone | 1d | 2014-04-02 | 2014-04-02 |  | 282d |  | start no earlier than 2014-04-02 |  | WG | 8h |
| 31 | 9.2 | A_COMP published |  | 1d | 2014-04-02 | 2014-04-02 |  | 282d |  | start no earlier than 2014-04-02 |  | WG | 8h |
| 32 | 9.3 | Publish 1415 Learning Activity codeset (look-up) | milestone | 1d | 2014-04-02 | 2014-04-02 |  | 282d |  | start no earlier than 2014-04-02 |  | WG | 8h |
| 33 | 9.4 | Publish 1415 Learning Activity Provider codeset (look-up) | milestone | 1d | 2014-04-02 | 2014-04-02 |  | 282d |  | start no earlier than 2014-04-02 |  | WG | 8h |
| 35 | 10 | **Develop January PLASC and EOTAS 2015** |  | 103d | 2014-02-11 | 2014-07-03 |  | 216d |  |  |  | WG | 1392h |
| 36 | 10.1 | **Specification** |  | 19d | 2014-02-11 | 2014-03-07 |  | 300d |  |  |  | WG | 296h |
| 37 | 10.1.1 | Draft specification release |  | 1d | 2014-02-11 | 2014-02-11 |  | 302d | 0d | start no earlier than 2014-02-11 |  | WG | 8h |
| 38 | 10.1.2 | Supplier review period |  | 16d | 2014-02-12 | 2014-03-05 | 37 | 302d |  | start no earlier than 2014-02-11 |  | Suppliers | 128h |
| 39 | 10.1.3 | Version 1 specification release | milestone | 1d | 2014-03-07 | 2014-03-07 |  | 300d |  | start no earlier than 2014-03-07 |  | WG | 8h |

Notes:
- 25: Consider January PLASC 2011, Post-16 Summer PLASC 2011 and Attendance 2011 specifications
- 36: Publication in the same bundle as Post-16 Summer PLASC 2011 and Attendance Collections 2011

| ID | WBS | Task | Type | Duration | Start | Finish | Predecessors | Total slack | Free slack | Constraint | Resources | Work |
| --- | --- | --- | --- | --- | --- | --- | --- | --- | --- | --- | --- | --- |
| 40 | 10.2 | **xslt development** |  | 19d | 2014-06-02 | 2014-06-26 |  | 221d |  |  | WG | 256h |
| 41 | 10.2.1 | Draft fileset release | milestone | 1d | 2014-06-02 | 2014-06-02 |  | 227d | 0d | start no earlier than 2014-06-02 | WG | 8h |
| 42 | 10.2.2 | Supplier review period |  | 11d | 2014-06-03 | 2014-06-17 | 41 | 227d | 6d | start no earlier than 2014-06-02 | Suppliers | 88h |
| 43 | 10.2.3 | Final fileset release | milestone | 1d | 2014-06-26 | 2014-06-26 | 42 | 221d |  | start no earlier than 2014-06-26 | WG | 8h |
| 44 | 10.3 | **DEWi developments** |  | 1d | 2014-07-03 | 2014-07-03 |  | 216d |  |  | M4/WG | 16h |
| 45 | 10.3.1 | Release to supplier test DEWi sites for PLASC & EOTAS 2015 | milestone | 1d | 2014-07-03 | 2014-07-03 |  | 216d |  | finish no earlier than 2014-07-03 | M4/WG | 8h |
| 46 | 11 | **January PLASC & EOTAS 2015 xslt and DEWi development** |  | 189d | 2014-04-15 | 2015-01-02 |  | 85d |  |  | M4/WG | 2064h |
| 47 | 11.1 | Jan & EOTAS 2015 xslt & DEWi development |  | 25d | 2014-04-15 | 2014-05-19 |  | 229d | 0d | start no earlier than 2014-04-15 | M4/WG | 200h |
| 48 | 11.2 | Jan & EOTAS 2015 xslt UAT |  | 9d | 2014-05-20 | 2014-05-30 | 47 | 229d | 1d | start no earlier than 2014-05-20 | M4/WG | 72h |
| 49 | 11.3 | Jan & EOTAS 2015 xslt draft fileset release | milestone | 1d | 2014-06-05 | 2014-06-05 | 48 | 236d |  | start no earlier than 2014-06-05 | M4/WG | 8h |
| 50 | 11.4 | Jan & EOTAS 2015 DEWi UAT |  | 8d | 2014-06-03 | 2014-06-12 | 48 | 228d | 9d | start no earlier than 2014-06-03 | M4/WG | 64h |
| 51 | 11.5 | Jan & EOTAS 2015 xslt supplier review period |  | 11d | 2014-06-06 | 2014-06-20 |  | 225d |  | start no earlier than 2014-06-06 | M4/WG | 88h |
| 52 | 11.6 | Jan & EOTAS 2015 xslt rework |  | 3d | 2014-06-23 | 2014-06-25 |  | 215d | 0d | start no earlier than 2014-06-23 | M4/WG | 24h |
| 53 | 11.7 | Jan & EOTAS 2015 xslt rework UAT |  | 2d | 2014-06-26 | 2014-06-27 | 52 | 215d | 0d | start no earlier than 2014-06-26 | M4/WG | 16h |
| 54 | 11.8 | Jan & EOTAS 2015 DEWi rework |  | 3d | 2014-06-26 | 2014-06-30 | 50, 52 | 219d |  | start no earlier than 2014-06-26 | M4/WG | 24h |
| 55 | 11.9 | Jan & EOTAS 2015 xslt final fileset release |  | 1d | 2014-06-30 | 2014-06-30 | 53 | 219d |  | start no earlier than 2014-06-30 | M4/WG | 8h |
| 56 | 11.10 | Jan & EOTAS 2015 Release to test DEWi site | milestone | 1d | 2014-06-30 | 2014-06-30 | 53 | 215d | 0d | start no earlier than 2014-06-30 | M4/WG | 8h |
| 57 | 11.11 | Jan & EOTAS 2015 DEWi UAT on test site |  | 3d | 2014-07-01 | 2014-07-03 | 56 | 215d | 0d | start no earlier than 2014-07-01 | M4/WG | 24h |
| 58 | 11.12 | Jan & EOTAS 2015 Release to supplier test DEWi site | milestone | 1d | 2014-07-04 | 2014-07-04 | 57 | 215d |  | start no earlier than 2014-07-04 | M4/WG | 8h |
| 59 | 11.13 | Jan & EOTAS 2015 Release to live DEWi site | milestone | 1d | 2015-01-02 | 2015-01-02 | 57 | 85d |  | start no earlier than 2015-01-02 | M4/WG | 8h |
| 61 | 12 | Data removal - PLASC 2014 data | milestone | 1d | 2014-08-22 | 2014-08-22 |  | 180d |  | start no earlier than 2014-08-22 | WG | 8h |
| 63 | 13 | Fixed reports for NDC 2014 |  | 21d | 2014-09-23 | 2014-10-21 |  | 137d | 0d | start no earlier than 2014-09-23 | WG | 168h |
| 64 | 14 | Data removal - NDC 2014 data | milestone | 1d | 2014-10-22 | 2014-10-22 | 63 | 137d |  | start no earlier than 2014-09-24 | WG | 8h |
| 65 | 15 | Data removal - Attendance 2014 | milestone | 1d | 2014-10-21 | 2014-10-21 |  | 138d |  | start no earlier than 2014-10-21 | WG | 8h |

Notes:
- 54: Including released learning activity and provider codeset look-ups on 1/4/10

| ID | WBS | Task | Type | Duration | Start | Finish | Predecessors | Total slack | Free slack | Constraint | Resources | Work |
| --- | --- | --- | --- | --- | --- | --- | --- | --- | --- | --- | --- | --- |
| 67 | 16 | **Develop Attendance 2014** |  | 166d | 2014-02-11 | 2014-09-30 |  | 153d |  |  | WG | 1856h |
| 68 | 16.1 | **Specification** |  | 21d | 2014-02-11 | 2014-03-11 |  | 298d |  |  | WG | 304h |
| 69 | 16.1.1 | Draft specification release | milestone | 1d | 2014-02-11 | 2014-02-11 |  | 303d | 0d | start no earlier than 2014-02-11 | WG | 8h |
| 70 | 16.1.2 | Supplier review period |  | 15d | 2014-02-12 | 2014-03-04 | 69 | 303d |  |  | Suppliers | 120h |
| 71 | 16.1.3 | Version 1 specification release | milestone | 1d | 2014-03-11 | 2014-03-11 |  | 298d |  | start no earlier than 2014-03-11 | WG | 8h |
| 72 | 16.2 | **xslt development** |  | 13d | 2014-09-10 | 2014-09-26 |  | 155d |  |  | WG | 208h |
| 73 | 16.2.1 | Draft fileset release | milestone | 1d | 2014-09-10 | 2014-09-10 |  | 155d | 0d | start no earlier than 2014-09-10 | WG | 8h |
| 74 | 16.2.2 | Supplier review period |  | 11d | 2014-09-11 | 2014-09-25 | 73 | 155d | 0d | start no earlier than 2014-09-11 | Suppliers | 88h |
| 75 | 16.2.3 | Final fileset release | milestone | 1d | 2014-09-26 | 2014-09-26 | 74 | 155d |  | start no earlier than 2014-09-01 | WG | 8h |
| 76 | 16.3 | **DEWi developments** |  | 1d | 2014-09-30 | 2014-09-30 |  | 153d |  |  | M4/WG | 16h |
| 77 | 16.3.1 | Release to supplier test DEWi sites for Attendance & NDC 2015 | milestone | 1d | 2014-09-30 | 2014-09-30 |  | 153d |  | start no earlier than 2014-09-30 | M4/WG | 8h |
| 79 | 17 | Attendance Primary 2014 Guidance Notes Released |  | 1d | 2014-06-27 | 2014-06-27 |  | 220d |  | start no earlier than 2014-06-27 | WG | 8h |
| 81 | 18 | Post-16 2014 Guidance Notes Released |  | 1d | 2014-07-03 | 2014-07-03 |  | 216d |  | start no earlier than 2014-07-03 | WG | 8h |
| 83 | 19 | **Summer Attendance & NDC 2015 xslt and DEWi development** |  | 199d | 2014-07-29 | 2015-05-01 |  | 0d |  |  | M4/WG | 2072h |
| 84 | 19.1 | Summer 2015 xslt and DEWi development |  | 20d | 2014-07-29 | 2014-08-25 |  | 151d | 0d | start no earlier than 2014-07-29 | M4/WG | 160h |
| 85 | 19.2 | Summer 2015 xslt UAT |  | 5d | 2014-08-26 | 2014-09-01 | 84 | 151d | 0d | start no earlier than 2014-08-26 | M4/WG | 40h |
| 86 | 19.3 | Summer 2015 xslt draft fileset release | milestone | 1d | 2014-09-02 | 2014-09-02 | 85 | 151d | 0d | start no earlier than 2014-09-02 | M4/WG | 8h |
| 87 | 19.4 | Summer 2015 xslt supplier review period |  | 11d | 2014-09-03 | 2014-09-17 | 86 | 151d | 0d | start no earlier than 2014-09-03 | M4/WG | 88h |
| 88 | 19.5 | Summer 2015 DEWi UAT |  | 5d | 2014-09-02 | 2014-09-08 | 85 | 163d | 7d | start no earlier than 2014-09-02 | M4/WG | 40h |
| 89 | 19.6 | Summer 2015 xslt rework |  | 4d | 2014-09-18 | 2014-09-23 | 87 | 151d | 0d | start no earlier than 2014-09-18 | M4/WG | 32h |
| 90 | 19.7 | Summer 2015 xslt rework UAT |  | 2d | 2014-09-24 | 2014-09-25 | 89 | 151d | 0d | start no earlier than 2014-09-24 | M4/WG | 16h |
| 91 | 19.8 | Summer 2015 DEWi rework |  | 5d | 2014-09-18 | 2014-09-24 | 87, 88 | 156d | 0d | start no earlier than 2014-09-18 | M4/WG | 40h |
| 92 | 19.9 | Summer 2015 Release to test DEWi site for NDC & Attendance collections 2014 |  | 1d | 2014-09-25 | 2014-09-25 | 91 | 156d |  | start no earlier than 2014-09-25 | M4/WG | 8h |
| 93 | 19.10 | Summer 2015 xslt final fileset release | milestone | 1d | 2014-09-26 | 2014-09-26 | 90 | 151d | 0d | start no earlier than 2014-09-26 | M4/WG | 8h |
| 94 | 19.11 | Summer 2015 DEWi UAT on test site |  | 3d | 2014-09-29 | 2014-10-01 | 93 | 151d | 0d | start no earlier than 2014-09-29 | M4/WG | 24h |
| 95 | 19.12 | Summer 2015 Release to supplier test DEWi site for NDC & Attendance collections 2014 | milestone | 1d | 2014-10-02 | 2014-10-02 | 94 | 151d |  | start no earlier than 2014-10-02 | M4/WG | 8h |
| 96 | 19.13 | Summer 2015 Release to live DEWi site for NDC & Attendance collections 2014 | milestone | 1d | 2015-05-01 | 2015-05-01 | 94 | 0d |  | start no earlier than 2015-05-01 | M4/WG | 8h |

Notes:
- 68: Publication in the same bundle as January PLASC 2012
- 72: Development in the same bundle as NDC 2012
- 76: Development in the same bundle as NDC 2012
- 83: Summer Post-16 PLASC, Attendance and NDC 2012

| ID | WBS | Task | Type | Duration | Start | Finish | Predecessors | Total slack | Free slack | Constraint | Resources | Work |
| --- | --- | --- | --- | --- | --- | --- | --- | --- | --- | --- | --- | --- |
| 98 | 20 | **Summer SDF meeting** |  | 17d | 2014-06-04 | 2014-06-26 |  | 221d |  |  | Suppliers | 272h |
| 99 | 20.1 | Software Development Forum meeting | milestone | 1d | 2014-06-04 | 2014-06-04 |  | 221d | 0d | start no earlier than 2014-06-04 | Suppliers/WG | 8h |
| 100 | 20.2 | Specification review period |  | 16d | 2014-06-05 | 2014-06-26 | 99 | 221d |  | start no earlier than 2014-06-05 | Suppliers | 128h |
| 101 | 21 | **Develop NDC 2015** |  | 89d | 2014-05-30 | 2014-10-01 |  | 152d |  |  | WG | 1336h |
| 102 | 21.1 | **Specification** |  | 20d | 2014-05-30 | 2014-06-26 |  | 221d |  |  | WG | 304h |
| 103 | 21.1.1 | Draft specification release | milestone | 1d | 2014-05-30 | 2014-05-30 |  | 223d | 2d | start no earlier than 2014-05-30 | WG | 8h |
| 104 | 21.1.2 | Supplier review period |  | 16d | 2014-06-04 | 2014-06-25 | 103 | 221d | 0d | start no earlier than 2014-06-04 | Suppliers | 128h |
| 105 | 21.1.3 | Version 1 specification release | milestone | 1d | 2014-06-26 | 2014-06-26 | 104 | 221d |  | start no earlier than 2014-06-24 | WG | 8h |
| 106 | 21.2 | **xslt development** |  | 19d | 2014-09-02 | 2014-09-26 |  | 155d |  |  | WG | 304h |
| 107 | 21.2.1 | Draft fileset release | milestone | 1d | 2014-09-02 | 2014-09-02 |  | 155d | 0d | start no earlier than 2014-09-02 | WG | 8h |
| 108 | 21.2.2 | Supplier review period |  | 11d | 2014-09-03 | 2014-09-17 | 107 | 155d | 0d | start no earlier than 2014-09-03 | Suppliers | 88h |
| 109 | 21.2.3 | Final fileset release | milestone | 7d | 2014-09-18 | 2014-09-26 | 108 | 155d |  | start no earlier than 2014-09-18 | WG | 56h |
| 110 | 21.3 | **DEWi developments** |  | 1d | 2014-10-01 | 2014-10-01 |  | 152d |  |  | M4/WG | 16h |
| 111 | 21.3.1 | Release to supplier test DEWi sites for Attendance & NDC 2014 | milestone | 1d | 2014-10-01 | 2014-10-01 |  | 152d |  | start no earlier than 2014-10-01 | M4/WG | 8h |
| 113 | 22 | DEWI user audit |  | 20d | 2014-09-01 | 2014-09-26 |  | 155d |  | start no earlier than 2014-09-01 | WG | 160h |
| 116 | 23 | **Autumn SDF meetings** |  | 25d | 2014-10-08 | 2014-11-11 |  | 123d |  |  | Suppliers | 216h |
| 117 | 23.1 | Software Development Forum meeting | milestone | 1d | 2014-10-08 | 2014-10-08 |  | 146d | 23d | start no earlier than 2014-10-08 | Suppliers/WG | 8h |
| 118 | 23.2 | Software Development Forum meeting | milestone | 1d | 2014-11-11 | 2014-11-11 | 117 | 123d |  | start no earlier than 2014-11-11 | Suppliers/WG | 8h |
| 121 | 24 | **Develop Post-16 September 2015** |  | 126d | 2014-03-18 | 2014-09-09 |  | 168d |  |  | WG | 2952h |
| 122 | 24.1 | **Specification** |  | 17d | 2014-03-18 | 2014-04-09 |  | 277d |  |  | WG | 280h |
| 123 | 24.1.1 | Draft specification release | milestone | 1d | 2014-03-18 | 2014-03-18 |  | 277d | 0d | start no earlier than 2014-03-18 | WG | 8h |
| 124 | 24.1.2 | Supplier review period |  | 16d | 2014-03-19 | 2014-04-09 | 123 | 277d |  | start no earlier than 2014-03-05 | Suppliers | 128h |
| 125 | 24.1.3 | Version 1 specification release | milestone | 1d | 2014-03-31 | 2014-03-31 |  | 284d |  | start no earlier than 2014-03-31 | WG | 8h |
| 126 | 24.2 | **xslt development** |  | 93d | 2014-04-08 | 2014-08-14 |  | 186d |  |  | WG | 856h |
| 127 | 24.2.1 | Draft fileset release | milestone | 1d | 2014-04-08 | 2014-04-08 |  | 266d | 0d | start no earlier than 2014-04-08 | WG | 8h |
| 128 | 24.2.2 | Supplier review period |  | 11d | 2014-04-09 | 2014-04-23 | 127 | 266d | 0d | start no earlier than 2014-04-09 | Suppliers | 88h |
| 129 | 24.2.3 | Final fileset release | milestone | 1d | 2014-04-24 | 2014-04-24 | 128 | 266d |  | start no earlier than 2014-03-31 | WG | 8h |
| 130 | 24.2.4 | Update of fileset release with 15/16 look-ups |  | 1d | 2014-08-14 | 2014-08-14 |  | 186d |  | start no earlier than 2014-08-14 | WG | 8h |

Notes:
- 100: Consider Post-16 September PLASC 2012 specification
- 106: Development in the same bundle as Post-16 Summer PLASC 2010 and Attendance Collections 2010
- 110: Development in the same bundle as Post-16 Summer PLASC 2010 and Attendance Collections 2010

| ID | WBS | Task | Type | Duration | Start | Finish | Predecessors | Total slack | Free slack | Constraint | Resources | Work |
| --- | --- | --- | --- | --- | --- | --- | --- | --- | --- | --- | --- | --- |
| 131 | 24.3 | **DEWi developments** |  | 99d | 2014-04-24 | 2014-09-09 |  | 168d |  |  | M4/WG | 808h |
| 132 | 24.3.1 | Release to supplier test DEWi sites for Post-16 September 2015 | milestone | 1d | 2014-04-24 | 2014-04-24 |  | 266d |  | start no earlier than 2014-04-24 | M4/WG | 8h |
| 133 | 24.3.2 | Release update with look-ups to supplier test DEWi site Post-16 September 2015 |  | 1d | 2014-09-09 | 2014-09-09 |  | 168d |  | start no earlier than 2014-09-09 | M4/WG | 8h |
| 135 | 25 | **Post-16 2015 xslt and DEWi development** |  | 131d | 2014-03-18 | 2014-09-16 |  | 163d |  |  | M4/WG | 1472h |
| 136 | 25.1 | Post-16 2015 xslt and DEWi development |  | 10d | 2014-03-18 | 2014-03-31 |  | 255d | 0d | start no earlier than 2014-03-18 | M4/WG | 80h |
| 137 | 25.2 | Post-16 2015 xslt UAT |  | 3d | 2014-04-01 | 2014-04-03 | 136 | 255d | 0d | start no earlier than 2014-03-17 | M4/WG | 24h |
| 138 | 25.3 | Post-16 2015 xslt draft fileset release | milestone | 1d | 2014-04-04 | 2014-04-04 | 137 | 255d | 0d | start no earlier than 2014-03-20 | M4/WG | 8h |
| 139 | 25.4 | Post-16 2015 xslt supplier review period |  | 11d | 2014-04-07 | 2014-04-21 | 138 | 255d | 0d | start no earlier than 2014-03-25 | M4/WG | 88h |
| 140 | 25.5 | Post-16 2015 DEWi UAT |  | 3d | 2014-04-04 | 2014-04-08 | 137 | 268d | 9d | start no earlier than 2014-03-20 | M4/WG | 24h |
| 141 | 25.6 | Post-16 2015 xslt rework |  | 3d | 2014-04-22 | 2014-04-24 | 139 | 255d | 0d | start no earlier than 2014-04-09 | M4/WG | 24h |
| 142 | 25.7 | Post-16 2015 xslt rework UAT |  | 2d | 2014-04-25 | 2014-04-28 | 141 | 255d | 0d | start no earlier than 2014-04-16 | M4/WG | 16h |
| 143 | 25.8 | Post-16 2015 DEWi rework |  | 5d | 2014-04-22 | 2014-04-28 | 139, 140 | 259d | 0d | start no earlier than 2014-04-09 | M4/WG | 40h |
| 144 | 25.9 | Post-16 2015 Release to test DEWi site |  | 1d | 2014-04-29 | 2014-04-29 | 143 | 259d | 0d | start no earlier than 2014-04-18 | M4/WG | 8h |
| 145 | 25.10 | Post-16 2015 xslt final fileset release | milestone | 1d | 2014-04-29 | 2014-04-29 | 142 | 255d | 0d | start no earlier than 2014-04-18 | M4/WG | 8h |
| 146 | 25.11 | Post-16 2015 DEWi UAT on test site |  | 3d | 2014-04-30 | 2014-05-02 | 144 | 259d | 0d | start no earlier than 2014-04-17 | M4/WG | 24h |
| 147 | 25.12 | Post-16 2015 Release to supplier test DEWi site | milestone | 1d | 2014-05-05 | 2014-05-05 | 146 | 259d |  | start no earlier than 2014-04-22 | M4/WG | 8h |
| 148 | 25.13 | Post-16 2015 xslt and DEWi inclusion of 15/16 look-ups |  | 4d | 2014-04-30 | 2014-05-05 | 145 | 255d | 85d | start no earlier than 2014-04-01 | M4/WG | 32h |
| 149 | 25.14 | Post-16 2015 xslt and DEWi UAT on 14/15 look-ups update |  | 3d | 2014-09-02 | 2014-09-04 | 148 | 170d | 5d | start no earlier than 2014-09-02 | M4/WG | 24h |
| 150 | 25.15 | Post-16 2015 xslt update release | milestone | 1d | 2014-09-12 | 2014-09-12 | 149 | 165d |  | start no earlier than 2014-09-12 | M4/WG | 8h |
| 151 | 25.16 | Post-16 2015 Release to live DEWi site | milestone | 1d | 2014-09-16 | 2014-09-16 | 149 | 163d |  | start no earlier than 2014-09-16 | M4/WG | 8h |
| 153 | 26 | CTF14 consultation |  | 21d | 2014-12-02 | 2014-12-30 |  | 88d |  | start no earlier than 2014-12-02 | WG | 168h |
| 155 | 27 | Jan PLASC & EOTAS 2015 Guidance Notes Released |  | 1d | 2014-10-24 | 2014-10-24 |  | 135d |  | start no earlier than 2014-10-24 | WG | 8h |
| 157 | 28 | Data removal - Post-16 September 2014 data | milestone | 1d | 2015-01-26 | 2015-01-26 |  | 69d |  | start no earlier than 2015-01-26 | WG | 8h |
| 159 | 29 | CTF14 draft release to suppliers |  | 20d | 2015-01-30 | 2015-02-26 |  | 46d |  | start no earlier than 2015-01-30 | WG | 160h |
